# Spectrometer Solenoids Ver1

Schedule from MS Project, 2010-10-28 to 2011-06-10.

## Calendars

- Standard: Mon-Fri 08:00-12:00, 13:00-17:00; Sat-Sun off. Exceptions (off unless hours are given): 2010-11-25 to 2010-11-26, 2010-12-25 to 2011-01-03.

## Schedule

| ID | WBS | Task | Type | Duration | Start | Finish | Predecessors | Total slack | Free slack | Constraint | Work |
| --- | --- | --- | --- | --- | --- | --- | --- | --- | --- | --- | --- |
| 1 | 1 | **Design - Magnet Modification** |  | 21d | 2010-11-15 | 2010-12-15 |  | 0d |  |  | 128h |
| 2 | 1.1 | Design new tower assembly |  | 3w | 2010-11-15 | 2010-12-07 |  | 0d |  | start no earlier than 2010-11-15 | 120h |
| 3 | 1.2 | Internal design review |  | 1d | 2010-12-08 | 2010-12-08 | 2 | 0d |  |  | 8h |
| 4 | 1.3 | Tower design accepted |  | 5d | 2010-12-09 | 2010-12-15 | 3 | 0d |  |  |  |
| 5 | 2 | **Engineering Drawings** |  | 60d | 2010-11-08 | 2011-02-09 |  | 87d |  |  | 560h |
| 6 | 2.1 | Sort drawing file from Wang |  | 2w | 2010-11-08 | 2010-11-19 |  | 82d | 0d | start no earlier than 2010-11-08 | 80h |
| 7 | 2.2 | Produce part models |  | 2mo | 2010-11-22 | 2011-01-26 | 6 | 82d | 0d |  | 320h |
| 8 | 2.3 | Produce assembly models |  | 1mo | 2011-01-13 | 2011-02-09 | 7FS-2w | 82d |  |  | 160h |
| 9 | 3 | **Fabrication and Assembly** |  | 139d | 2010-10-28 | 2011-05-20 |  | 15d |  |  | 960h |
| 10 | 3.1 | **Fabrication** |  | 136d | 2010-10-28 | 2011-05-17 |  | 18d |  |  | 744h |
| 11 | 3.1.1 | **Cold Mass for Solenoid 1** |  | 39.5d | 2010-11-15 | 2011-01-19 |  | 16d |  |  | 180h |
| 12 | 3.1.1.1 | Open cold mass and stabalise leads |  | 1w | 2010-11-15 | 2010-11-19 |  | 11d | 0d | start no earlier than 2010-11-15 | 40h |
| 13 | 3.1.1.2 | Machine 5 holes for the cryo coolers |  | 1w | 2010-12-16 | 2010-12-22 | 12, 4 | 0d |  |  | 40h |
| 14 | 3.1.1.3 | Insert Bimetal inserts into holes |  | 2d | 2010-12-23 | 2010-12-24 | 13 | 0d |  |  | 16h |
| 15 | 3.1.1.4 | Weld cooler tubes and bellow |  | 2d | 2011-01-04 | 2011-01-05 | 14 | 0d |  |  | 16h |
| 16 | 3.1.1.5 | Upgrade vent and fill line |  | 3d | 2011-01-06 | 2011-01-10 | 15 | 0d |  |  | 24h |
| 17 | 3.1.1.6 | Install top fill line |  | 2d | 2011-01-11 | 2011-01-12 | 16 | 106.5d | 0d |  | 16h |
| 18 | 3.1.1.7 | Install heat intercept to main fill line |  | 4h | 2011-01-11 | 2011-01-11 | 16 | 0d |  |  | 4h |
| 19 | 3.1.1.8 | Install 4K lead heat intercepts |  | 1d | 2011-01-11 | 2011-01-12 | 18 | 107.5d |  |  | 8h |
| 20 | 3.1.1.9 | Vacuum leak check |  | 2d | 2011-01-11 | 2011-01-13 | 18 | 0d |  |  | 16h |
| 21 | 3.1.1.10 | Cold mass ready for installation | milestone | 0d | 2011-01-19 | 2011-01-19 | 49 | 0d |  |  |  |
| 22 | 3.1.2 | **Radiation Shield for Solenoid 1** |  | 12d | 2011-01-19 | 2011-02-04 |  | 0d |  |  | 96h |
| 23 | 3.1.2.1 | Remove LN2 resevoir |  | 2d | 2011-01-19 | 2011-01-21 | 21 | 0d |  |  | 16h |
| 24 | 3.1.2.2 | Add holes for extra cryo coolers |  | 3d | 2011-01-21 | 2011-01-26 | 23 | 0d |  |  | 24h |
| 25 | 3.1.2.3 | Remove origional cooler connections |  | 1d | 2011-01-26 | 2011-01-27 | 24 | 0d |  |  | 8h |
| 26 | 3.1.2.4 | Weld copper to Aluminium transition strips |  | 1d | 2011-01-27 | 2011-01-28 | 25 | 0d |  |  | 8h |
| 27 | 3.1.2.5 | Weld on copper plates |  | 1d | 2011-01-28 | 2011-01-31 | 26 | 0d |  |  | 8h |
| 28 | 3.1.2.6 | Weld Aluminium banding for intercepts |  | 3d | 2011-01-31 | 2011-02-03 | 27 | 0d |  |  | 24h |
| 29 | 3.1.2.7 | Check / machine split for Eddy currents |  | 1d | 2011-02-03 | 2011-02-04 | 28 | 0d |  |  | 8h |
| 30 | 3.1.2.8 | Radiation Shield ready for installation | milestone | 0d | 2011-02-04 | 2011-02-04 | 29 | 90.5d |  |  |  |

| ID | WBS | Task | Type | Duration | Start | Finish | Predecessors | Total slack | Free slack | Work |
| --- | --- | --- | --- | --- | --- | --- | --- | --- | --- | --- |
| 31 | 3.1.3 | **Cooler Tower** |  | 22.5d | 2011-03-02 | 2011-04-01 |  | 0d |  | 140h |
| 32 | 3.1.3.1 | Manufacture new tower plates |  | 1w | 2011-03-02 | 2011-03-09 | 88 | 0d |  | 40h |
| 33 | 3.1.3.2 | Weld top and end plates to Vacuum vessel |  | 3d | 2011-03-09 | 2011-03-14 | 32 | 0d |  | 24h |
| 34 | 3.1.3.3 | Install cooler sleeves and copper plates |  | 2d | 2011-03-14 | 2011-03-16 | 33 | 0d |  | 16h |
| 35 | 3.1.3.4 | Weld cooler sleeves to cold mass |  | 2d | 2011-03-16 | 2011-03-18 | 34 | 0d |  | 16h |
| 36 | 3.1.3.5 | Install Copper straps between 1st stage and Copper plates |  | 1d | 2011-03-21 | 2011-03-22 | 77 | 0d |  | 8h |
| 37 | 3.1.3.6 | Install the warm leads and HV feedthroughs |  | 1d | 2011-03-22 | 2011-03-23 | 36 | 0d |  | 8h |
| 38 | 3.1.3.7 | Install the heat intercepts to Copper plates |  | 4h | 2011-03-23 | 2011-03-23 | 37 | 0d |  | 4h |
| 39 | 3.1.3.8 | Install thermal connection from 1st stage Copper plates to Shield |  | 1d | 2011-03-25 | 2011-03-25 | 71 | 0d |  | 8h |
| 40 | 3.1.3.9 | Weld plates front and back |  | 2d | 2011-03-31 | 2011-04-01 | 56 | 0d |  | 16h |
| 41 | 3.1.4 | **Fill and Vent Tower** |  | 9d | 2011-04-26 | 2011-05-06 |  | 0d |  | 72h |
| 42 | 3.1.4.1 | Install and weld lower sections of tower to Vacuum vessel |  | 2d | 2011-04-26 | 2011-04-27 | 93 | 0d |  | 16h |
| 43 | 3.1.4.2 | Install instrumentation feedthrough |  | 1d | 2011-04-28 | 2011-04-28 | 42 | 0d |  | 8h |
| 44 | 3.1.4.3 | Check all instrumentation lines for activity |  | 1d | 2011-04-29 | 2011-04-29 | 43 | 0d |  | 8h |
| 45 | 3.1.4.4 | Weld the upper portion of the tower |  | 2d | 2011-05-02 | 2011-05-03 | 44 | 0d |  | 16h |
| 46 | 3.1.4.5 | Complete assembly of fill and vent tower and install |  | 3d | 2011-05-04 | 2011-05-06 | 45 | 0d |  | 24h |
| 47 | 3.1.5 | **MLI** |  | 69.5d | 2011-01-13 | 2011-04-20 |  | 0d |  | 168h |
| 48 | 3.1.5.1 | Wrap cold mass 1 with MLI |  | 4d | 2011-01-13 | 2011-01-19 | 20 | 0d |  | 32h |
| 49 | 3.1.5.2 | Sign off quality of MLI layers on cold mass 1 | milestone | 0d | 2011-01-19 | 2011-01-19 | 48 | 0d |  |  |
| 50 | 3.1.5.3 | Wrap radiation shield 1 with MLI |  | 3d | 2011-02-07 | 2011-02-10 | 69 | 0d |  | 24h |
| 51 | 3.1.5.4 | Sign off quality of MIL layers on radiation shield 1 | milestone | 0d | 2011-02-10 | 2011-02-10 | 50 | 0d |  |  |
| 52 | 3.1.5.5 | Wrap cold mass supports with MLI |  | 2d | 2011-02-14 | 2011-02-16 | 82 | 0d |  | 16h |
| 53 | 3.1.5.6 | Sign off quality of MLI wrap around supports | milestone | 0d | 2011-02-16 | 2011-02-16 | 52 | 82.5d |  |  |
| 54 | 3.1.5.7 | Wrap upper and lower tower area with MLI |  | 2d | 2011-03-28 | 2011-03-29 | 39 | 0d |  | 16h |
| 55 | 3.1.5.8 | Wrap 1st stage Copper plates to shield connections |  | 1d | 2011-03-30 | 2011-03-30 | 54 | 0d |  | 8h |
| 56 | 3.1.5.9 | Sign off Tower MLI wrapping | milestone | 0d | 2011-03-30 | 2011-03-30 | 55 | 0d |  |  |
| 57 | 3.1.5.10 | Apply MLI to Shield and cold mass bore |  | 3d | 2011-04-04 | 2011-04-06 | 40 | 0d |  | 24h |
| 58 | 3.1.5.11 | Sign off Shield and cold mass bore wrapping | milestone | 0d | 2011-04-06 | 2011-04-06 | 57 | 0d |  |  |
| 59 | 3.1.5.12 | Integrate cold mass MLI with bore MLI |  | 1d | 2011-04-12 | 2011-04-12 | 90 | 43d | 0d | 8h |
| 60 | 3.1.5.13 | Sign off cold mass to bore MLI conection | milestone | 0d | 2011-04-12 | 2011-04-12 | 59 | 43d |  |  |
| 61 | 3.1.5.14 | Apply MLI to shield ends |  | 2d | 2011-04-13 | 2011-04-14 | 91 | 0d |  | 16h |
| 62 | 3.1.5.15 | Apply MLI between warm bore and shield bore |  | 2d | 2011-04-15 | 2011-04-18 | 61 | 0d |  | 16h |
| 63 | 3.1.5.16 | Sign off shield MLI and warm bore MLI | milestone | 0d | 2011-04-18 | 2011-04-18 | 62, 61 | 0d |  |  |
| 64 | 3.1.5.17 | Integrate MLI between warm bore and shield ends |  | 1d | 2011-04-20 | 2011-04-20 | 92 | 0d |  | 8h |
| 65 | 3.1.5.18 | Sign off MLI at warm bore / shield connection | milestone | 0d | 2011-04-20 | 2011-04-20 | 64 | 0d |  |  |

| ID | WBS | Task | Type | Duration | Start | Finish | Predecessors | Total slack | Free slack | Work |
| --- | --- | --- | --- | --- | --- | --- | --- | --- | --- | --- |
| 66 | 3.1.6 | **Instrumentation** |  | 94d | 2010-11-23 | 2011-04-13 |  | 42d |  | 36h |
| 67 | 3.1.6.1 | Install level sensor cold mass 1 - new fill line / vent line |  | 4h | 2011-01-13 | 2011-01-13 | 17 | 106.5d |  | 4h |
| 68 | 3.1.6.2 | Install external temp sensors cold mass 1 |  | 4h | 2010-11-23 | 2010-11-23 | 74 | 130.5d |  | 4h |
| 69 | 3.1.6.3 | Install temp sensors radiation shield 1 |  | 1d | 2011-02-04 | 2011-02-07 | 29 | 0d |  | 8h |
| 70 | 3.1.6.4 | Add temp sensors to cold mass supports |  | 1d | 2011-02-14 | 2011-02-15 | 82 | 83.5d |  | 8h |
| 71 | 3.1.6.5 | Attach thermal sensors to the Copper plates |  | 4h | 2011-03-24 | 2011-03-24 | 75 | 0d |  | 4h |
| 72 | 3.1.6.6 | Apply thermal instramentation top shield |  | 1d | 2011-04-13 | 2011-04-13 | 91 | 42d |  | 8h |
| 73 | 3.1.7 | **Current Leads** |  | 80.5d | 2010-11-22 | 2011-03-24 |  | 56d |  | 12h |
| 74 | 3.1.7.1 | Connect external power leads to heat sink cold mass 1 |  | 1d | 2010-11-22 | 2010-11-22 | 12 | 130.5d | 0d | 8h |
| 75 | 3.1.7.2 | Install HTS leads with upper and lower voltage taps |  | 4h | 2011-03-24 | 2011-03-24 | 38 | 0d |  | 4h |
| 76 | 3.1.8 | **Coolers** |  | 136d | 2010-10-28 | 2011-05-17 |  | 18d |  | 40h |
| 77 | 3.1.8.1 | Install Single stage cooler to Tower |  | 1d | 2011-03-18 | 2011-03-21 | 35 | 0d |  | 8h |
| 78 | 3.1.8.2 | Install the 2 stage coolers to sleeves |  | 2d | 2011-05-13 | 2011-05-16 | 94 | 0d |  | 16h |
| 79 | 3.1.8.3 | Install cro cooler hoses |  | 1d | 2011-05-17 | 2011-05-17 | 78 | 0d |  | 8h |
| 80 | 3.1.8.4 | Recharge for UK operation |  | 1d | 2010-10-28 | 2010-10-28 |  | 148d |  | 8h |
| 81 | 3.2 | **Assembly** |  | 71.5d | 2011-02-10 | 2011-05-20 |  | 0d |  | 216h |
| 82 | 3.2.1 | Suspend shield around the cold mass |  | 2d | 2011-02-10 | 2011-02-14 | 51 | 0d |  | 16h |
| 83 | 3.2.2 | Install cold mass supports to Vacuum vessel |  | 2d | 2011-02-16 | 2011-02-18 | 52 | 0d |  | 16h |
| 84 | 3.2.3 | Move vacuum vessel over the shield / cold mass assembly |  | 2d | 2011-02-18 | 2011-02-22 | 83 | 0d |  | 16h |
| 85 | 3.2.4 | Connect the supports to the cold mass |  | 2d | 2011-02-22 | 2011-02-24 | 84 | 0d |  | 16h |
| 86 | 3.2.5 | Suspend the shield inside the vacuum vessel |  | 2d | 2011-02-24 | 2011-02-28 | 85 | 0d |  | 16h |
| 87 | 3.2.6 | Connect cold mass support intercepts to the shield |  | 1d | 2011-02-28 | 2011-03-01 | 86 | 0d |  | 8h |
| 88 | 3.2.7 | Add copper sheet to the holes in the shield |  | 1d | 2011-03-01 | 2011-03-02 | 87 | 0d |  | 8h |
| 89 | 3.2.8 | Align Vacuum vessel end plate to the cold mass bore |  | 2d | 2011-04-07 | 2011-04-08 | 58 | 0d |  | 16h |
| 90 | 3.2.9 | Install shield bore tube |  | 1d | 2011-04-11 | 2011-04-11 | 89 | 0d |  | 8h |
| 91 | 3.2.10 | Weld shield end plates |  | 1d | 2011-04-12 | 2011-04-12 | 90 | 0d |  | 8h |
| 92 | 3.2.11 | Install warm bore |  | 1d | 2011-04-19 | 2011-04-19 | 63 | 0d |  | 8h |
| 93 | 3.2.12 | Weld end plates to the Vacuum vessel |  | 3d | 2011-04-21 | 2011-04-25 | 65 | 0d |  | 24h |
| 94 | 3.2.13 | Detailed leak checking of the Vacuum vessel and cold mass |  | 4d | 2011-05-09 | 2011-05-12 | 46 | 0d |  | 32h |
| 95 | 3.2.14 | Install vacuum system to solenoid |  | 1d | 2011-05-18 | 2011-05-18 | 79 | 0d |  | 8h |
| 96 | 3.2.15 | Connect power leads from feedthroughs to vacuum vessel terminal block |  | 1d | 2011-05-19 | 2011-05-19 | 95 | 0d |  | 8h |
| 97 | 3.2.16 | Connect all instrumentation cables |  | 1d | 2011-05-20 | 2011-05-20 | 96 | 0d |  | 8h |
| 98 | 3.2.17 | Solenoid ready for cool down and training | milestone | 0d | 2011-05-20 | 2011-05-20 | 97 | 0d |  |  |

| ID | WBS | Task | Duration | Start | Finish | Predecessors | Total slack | Work |
| --- | --- | --- | --- | --- | --- | --- | --- | --- |
| 99 | 4 | **Training and Operations** | 15d | 2011-05-23 | 2011-06-10 |  | 0d | 32h |
| 100 | 4.1 | LN2 Cooldown | 3d | 2011-05-23 | 2011-05-25 | 98 | 0d | 8h |
| 101 | 4.2 | He Cooldown | 2d | 2011-05-26 | 2011-05-27 | 100 | 0d | 8h |
| 102 | 4.3 | Coil Training | 5d | 2011-05-30 | 2011-06-03 | 101 | 0d | 8h |
| 103 | 4.4 | Operation for Acceptance Testing | 2d | 2011-06-06 | 2011-06-07 | 102 | 0d | 8h |
| 104 | 4.5 | Magnet Warm-up | 3d | 2011-06-08 | 2011-06-10 | 103 | 0d |  |
